# T2.4 Installation

Schedule from MS Project, 2010-10-04 to 2010-11-12.
University of Sheffield

## Calendars

- Standard: Mon-Fri 08:00-12:00, 13:00-17:00; Sat-Sun off.

## Resources

| Resource |
| --- |
| 400 |
| 400k |

## Schedule

| ID | Task | Duration | Start | Finish | Predecessors | Total slack | Constraint | Resources | Work |
| --- | --- | --- | --- | --- | --- | --- | --- | --- | --- |
| 1 | T2.4 Assembly | 2d | 2010-10-04 | 2010-10-05 |  | 0d | start no earlier than 2010-10-04 |  |  |
| 2 | Electronics Commissioning R78 | 1d? | 2010-10-04 | 2010-10-04 |  | 29d | start no earlier than 2010-10-04 |  |  |
| 3 | T2.4 Installation | 1d? | 2010-10-06 | 2010-10-06 | 1 | 0d |  |  |  |
| 4 | T2.4 Commissioning | 1d? | 2010-10-07 | 2010-10-07 | 3 | 0d |  |  |  |
| 5 | Test Run 1 | 4d | 2010-10-08 | 2010-10-13 | 4 | 0d |  | 400k | 32h |
| 6 | Run 1 Inspection | 1d | 2010-10-14 | 2010-10-14 | 5 | 0d |  |  |  |
| 7 | Test Run 2 | 4d | 2010-10-15 | 2010-10-20 | 6 | 0d |  | 400k | 32h |
| 8 | Run 2 Inspection | 1d? | 2010-10-21 | 2010-10-21 | 7 | 0d |  |  |  |
| 9 | Test Run 3 | 4d | 2010-10-22 | 2010-10-27 | 8 | 0d | start no earlier than 2010-10-15 | 400k | 32h |
| 10 | Run 3 Inspection | 1d? | 2010-10-28 | 2010-10-28 | 9 | 0d | start no earlier than 2010-10-21 |  |  |
| 11 | Test Run 4 | 4d | 2010-10-29 | 2010-11-03 | 10 | 0d |  | 400k | 32h |
| 12 | Run 4 Inspection | 1d? | 2010-11-04 | 2010-11-04 | 11 | 0d |  |  |  |
| 13 | Test Run 5 | 4d | 2010-11-05 | 2010-11-10 | 12 | 0d |  | 400k | 32h |
| 14 | Run 5 Inspection | 1d? | 2010-11-11 | 2010-11-11 | 13 | 0d |  |  |  |
| 15 | Decisons | 1d? | 2010-11-12 | 2010-11-12 | 14 | 0d |  |  |  |
