# T2_installation_Mk2

Schedule from MS Project, 2009-10-12 to 2009-11-04.
University of Sheffield

## Calendars

- RAL-1: Mon-Fri 08:00-12:00, 13:00-17:00; Sat-Sun off. Exceptions (off unless hours are given): 2009-10-17 to 2009-12-20 08:00-12:00, 13:00-17:00 (Weekend).

## Schedule

| ID | WBS | Task | Type | Duration | Start | Finish | Predecessors | Total slack | Constraint |
| --- | --- | --- | --- | --- | --- | --- | --- | --- | --- |
| 2 | 1 | T2 Assembly |  | 2d | 2009-10-12 | 2009-10-13 |  | 0d | start no earlier than 2009-10-12 |
| 3 | 2 | Electronics Commissioning R78 |  | 1d? | 2009-10-12 | 2009-10-12 |  | 7d | start no earlier than 2009-10-12 |
| 4 | 3 | T2 Installation |  | 1d? | 2009-10-14 | 2009-10-14 | 2 | 0d |  |
| 5 | 4 | T2 Test Pulses (400k) |  | 5d | 2009-10-15 | 2009-10-19 | 4 | 0d |  |
| 6 | 5 | T2 Removal for inspection | milestone | 1d? | 2009-10-20 | 2009-10-20 | 5 | 0d |  |
| 7 | 6 | T2 Reassembly |  | 1d? | 2009-10-21 | 2009-10-21 | 6 | 0d |  |
| 8 | 7 | High speed photography |  | 1d? | 2009-10-22 | 2009-10-22 | 7 | 0d |  |
| 9 | 8 | Continuous operation |  | 13d | 2009-10-23 | 2009-11-04 | 8 | 0d |  |
