# Target Commissioning

Schedule from MS Project, 2009-08-12 to 2009-08-31.
University of Sheffield

## Calendars

- Standard: Mon-Fri 08:00-12:00, 13:00-17:00; Sat-Sun off.

## Schedule

| ID | Task | Type | Duration | Start | Finish | Predecessors | Total slack | Free slack |
| --- | --- | --- | --- | --- | --- | --- | --- | --- |
| 1 | Target 1 Assembly |  | 2d | 2009-08-12 | 2009-08-13 |  | 0d |  |
| 2 | Target 1 test rig installation |  | 2d | 2009-08-14 | 2009-08-17 | 1 | 0d |  |
| 3 | Target 1 Test |  | 1d | 2009-08-18 | 2009-08-18 | 2, 12 | 8d | 0d |
| 4 | Target 2 Assembly |  | 2d | 2009-08-18 | 2009-08-19 | 2 | 0d |  |
| 5 | Target 2 Test Rig Installation |  | 1d | 2009-08-20 | 2009-08-20 | 4 | 0d |  |
| 6 | Target 2 Position Measurement |  | 1d | 2009-08-21 | 2009-08-21 | 5 | 0d |  |
| 7 | Target 2 Test Run |  | 4d | 2009-08-24 | 2009-08-27 | 6 | 0d |  |
| 8 | Target 1 ISIS Installation |  | 1d | 2009-08-19 | 2009-08-19 | 3, 13 | 8d | 0d |
| 9 | Milestone 1 | milestone | 0d | 2009-08-19 | 2009-08-19 | 8 | 8d |  |
| 10 | Target 2 Removal and Inspection |  | 1d | 2009-08-28 | 2009-08-28 | 7 | 0d |  |
| 11 | Target 2 Reinstallation |  | 1d | 2009-08-31 | 2009-08-31 | 10 | 0d |  |
| 12 | Electronics Commissioning R78 |  | 2d | 2009-08-12 | 2009-08-13 |  | 10d | 0d |
| 13 | Electronics Commisioning MLCR |  | 1d | 2009-08-14 | 2009-08-14 | 12 | 10d |  |
